Schedule from MS Project, 2016-10-02 to 2016-12-26, costs in Rp, A marks actual dates.

## Calendars

- Standard: Mon-Fri 08:00-12:00, 13:00-17:00; Sat-Sun off. Exceptions (off unless hours are given): 2016-10-03 (libur).

## Resources

| Resource | Unit | Rate |
| --- | --- | --- |
| MANDOR |  | 12500 |
| KEPALA TUKANG |  | 11250 |
| TUKANG BATU |  | 10000 |
| TUKANG KAYU |  | 10000 |
| PEKERJA |  | 7500 |
| AIR | LITER | 100 |
| BALOK KAYU | M3 | 500000 |
| BATU MERAH | BUAH | 500 |
| FLOOR DRAIN | BUAH | 20000 |
| GYPSUM BOARD | M2 | 125000 |
| KASO-KASO (5X7)cm | M3 | 40000 |
| KAWAT BETON | M3 | 15000 |
| KERIKIL | M3 | 400000 |
| KLOSET | BUAH | 180000 |
| MINYAK BEKISTING | LITER | 15000 |
| PAKU | KG | 10000 |
| PAPAN KAYU | LEMBAR | 1000000 |
| PASIR BETON | M3 | 500000 |
| PASIR PASANG | M3 | 500000 |
| PASIR URUG | M3 | 500000 |
| SEMEN | ZA | 55000 |
| RENG (2X3)CM | M3 | 25000 |
| WESTAFEL | BUAH | 180000 |
| SENG | LEMBAR | 55000 |
| GENTENG METAL |  | 70000 |

## Schedule

| ID | WBS | Task | Duration | Start | Finish | Predecessors | Complete | Remaining | Total slack | Free slack | Resources | Work | Actual work | Cost | Actual cost |
| --- | --- | --- | --- | --- | --- | --- | --- | --- | --- | --- | --- | --- | --- | --- | --- |
| 1 | 1 | **PROYEK RUMAH DUA LANTAI** | 60d | 2016-10-02 A | 2016-12-26 |  | 8% | 55.39d | 0d |  |  | 888h | 451.12h | 15,265,000 | 8,414,175.19 |
| 2 | 1.1 | **PEKERJAAN PERSIAPAN** | 21d | 2016-10-04 A | 2016-11-01 |  | 45% | 11.46d | 39d |  |  | 888h | 451.12h | 15,265,000 | 8,414,175.19 |
| 3 | 1.1.1 | PEMBERSIHAN LAHAN | 2d | 2016-10-04 A | 2016-10-05 |  | 50% | 1d | 7.58d | 0d | KEPALA TUKANG [200%]; TUKANG KAYU [200%]; PAKU [10 KG]; SENG [12 LEMBAR] | 64h | 32h | 1,440,000 | 720,000 |
| 4 | 1.1.2 | PEMBUATAN BOWPLANK | 8.33d | 2016-10-06 A | 2016-11-01 | 3 | 43% | 4.75d | 0d |  | TUKANG BATU [1000%]; MANDOR [300%]; PAKU [10 KG]; SEMEN [5 ZA]; KERIKIL [7 M3]; KEPALA TUKANG [200%] | 224h | 110h | 5,875,000 | 4,164,250 |
| 5 | 1.1.3 | PEMBUATAN BEDENG | 6.6d | 2016-10-06 A | 2016-10-17 | 4SS | 54% | 3.04d | 50.5d |  | MANDOR [500%]; PEKERJA [900%]; TUKANG BATU [1000%]; SENG [3 LEMBAR]; SEMEN [3 ZA]; KASO-KASO (5X7)cm [2 M3]; KERIKIL [1 M3] | 528h | 309.12h | 6,090,000 | 3,529,925.19 |
| 6 | 1.1.4 | PEMBUATAN PAGAR PROYEK | 1d | 2016-10-06 | 2016-10-06 | 4SS |  |  | 57d |  | KEPALA TUKANG [200%]; TUKANG KAYU [300%]; PEKERJA [400%]; SENG [20 LEMBAR]; PAKU [10 KG] | 72h |  | 1,860,000 |  |
| 7 | 1.2 | **PEKERJAAN TANAH** | 30d | 2016-11-02 | 2016-12-13 |  |  |  | 0d |  |  |  |  |  |  |
| 8 | 1.2.1 | **GALIAN** | 4d | 2016-11-02 | 2016-11-07 |  |  |  | 0d |  |  |  |  |  |  |
| 9 | 1.2.1.1 | GALIAN TANAH PONDASI BATU KALI | 2d | 2016-11-02 | 2016-11-03 | 4 |  |  | 0d |  |  |  |  |  |  |
| 10 | 1.2.1.2 | GALIAN TANAH PONDASI SUMURAN | 2d | 2016-11-02 | 2016-11-03 | 9SS |  |  | 37d |  |  |  |  |  |  |
| 11 | 1.2.1.3 | GALIAN SEPTICTANK | 1d | 2016-11-02 | 2016-11-02 | 9SS |  |  | 38d |  |  |  |  |  |  |
| 12 | 1.2.1.4 | GALIAN KOLAM RENANG | 2d | 2016-11-04 | 2016-11-07 | 22SS |  |  | 35d |  |  |  |  |  |  |
| 13 | 1.2.2 | **TIMBUNAN** | 22d | 2016-11-14 | 2016-12-13 |  |  |  | 9d |  |  |  |  |  |  |
| 14 | 1.2.2.1 | URUGAN PASIR | 2d | 2016-12-12 | 2016-12-13 | 56SS |  |  | 9d |  |  |  |  |  |  |
| 15 | 1.2.2.2 | URUGAN TANAH | 2d | 2016-11-14 | 2016-11-15 | 25SS |  |  | 29d |  |  |  |  |  |  |
| 16 | 1.3 | **PEKERJAAN PONDASI** | 9d | 2016-11-04 | 2016-11-16 |  |  |  | 0d |  |  |  |  |  |  |
| 17 | 1.3.1 | **PONDASI BATU KALI** | 6d | 2016-11-04 | 2016-11-11 |  |  |  | 4d |  |  |  |  |  |  |
| 18 | 1.3.1.1 | LANTAI KERJA | 2d | 2016-11-04 | 2016-11-07 | 9 |  |  | 35d |  |  |  |  |  |  |
| 19 | 1.3.1.2 | AANSTAMPANG | 1d | 2016-11-04 | 2016-11-04 | 22SS |  |  | 36d |  |  |  |  |  |  |
| 20 | 1.3.1.3 | PEMASANGAN BATU KALI | 2d | 2016-11-10 | 2016-11-11 | 23 |  |  | 0d |  |  |  |  |  |  |
| 21 | 1.3.2 | **PONDASI SUMURAN** | 9d | 2016-11-04 | 2016-11-16 |  |  |  | 0d |  |  |  |  |  |  |
| 22 | 1.3.2.1 | LANTAI KERJA | 2d | 2016-11-04 | 2016-11-07 | 9 |  |  | 0d |  |  |  |  |  |  |
| 23 | 1.3.2.2 | PEMASANGAN CINCIN SUMURAN | 2d | 2016-11-08 | 2016-11-09 | 22 |  |  | 0d |  |  |  |  |  |  |
| 24 | 1.3.2.3 | PEMBESIAN SUMURAN | 3d | 2016-11-10 | 2016-11-14 | 20SS |  |  | 30d |  |  |  |  |  |  |
| 25 | 1.3.2.4 | CYCLOPEN | 2d | 2016-11-14 | 2016-11-15 | 20 |  |  | 0d |  |  |  |  |  |  |
| 26 | 1.3.2.5 | POER | 1d | 2016-11-16 | 2016-11-16 | 25 |  |  | 0d |  |  |  |  |  |  |

| ID | WBS | Task | Duration | Start | Finish | Predecessors | Total slack |
| --- | --- | --- | --- | --- | --- | --- | --- |
| 27 | 1.4 | **PEKERJAAN BETON BERTULANG** | 21d | 2016-11-16 | 2016-12-14 |  | 1d |
| 28 | 1.4.1 | **SLOOF** | 4d | 2016-11-16 | 2016-11-21 |  | 1d |
| 29 | 1.4.1.1 | PEMBESIAN | 3d | 2016-11-16 | 2016-11-18 | 26SS | 26d |
| 30 | 1.4.1.2 | BEKISTING | 2d | 2016-11-17 | 2016-11-18 | 26 | 0d |
| 31 | 1.4.1.3 | PENGECORAN | 1d | 2016-11-21 | 2016-11-21 | 35SS | 25d |
| 32 | 1.4.2 | **KOLOM LANTAI 1** | 6d | 2016-11-17 | 2016-11-24 |  | 2d |
| 33 | 1.4.2.1 | **KOLOM 30 X 30** | 5d | 2016-11-17 | 2016-11-23 |  | 2d |
| 34 | 1.4.2.1.1 | PEMBESIAN | 3d | 2016-11-17 | 2016-11-21 | 30SS | 25d |
| 35 | 1.4.2.1.2 | BEKISTING | 2d | 2016-11-21 | 2016-11-22 | 30 | 0d |
| 36 | 1.4.2.1.3 | PENGECORAN | 1d | 2016-11-23 | 2016-11-23 | 35 | 0d |
| 37 | 1.4.2.2 | **KOLOM 15 X 15** | 6d | 2016-11-17 | 2016-11-24 |  | 22d |
| 38 | 1.4.2.2.1 | PEMBESIAN | 3d | 2016-11-17 | 2016-11-21 | 30SS | 25d |
| 39 | 1.4.2.2.2 | BEKISTING | 2d | 2016-11-23 | 2016-11-24 | 35 | 22d |
| 40 | 1.4.2.2.3 | PENGECORAN | 1d | 2016-11-23 | 2016-11-23 | 36SS | 23d |
| 41 | 1.4.3 | **KOLOM LANTAI 2** | 7d | 2016-11-28 | 2016-12-06 |  | 4d |
| 42 | 1.4.3.1 | **KOLOM 30 X 30** | 7d | 2016-11-28 | 2016-12-06 |  | 4d |
| 43 | 1.4.3.1.1 | PEMBESIAN | 3d | 2016-11-28 | 2016-11-30 | 51SS | 18d |
| 44 | 1.4.3.1.2 | BEKISTING | 2d | 2016-12-02 | 2016-12-05 | 53 | 0d |
| 45 | 1.4.3.1.3 | PENGECORAN | 1d | 2016-12-06 | 2016-12-06 | 44 | 0d |
| 46 | 1.4.3.2 | **KOLOM 15 X 15** | 7d | 2016-11-28 | 2016-12-06 |  | 14d |
| 47 | 1.4.3.2.1 | PEMBESIAN | 3d | 2016-11-28 | 2016-11-30 | 51SS | 18d |
| 48 | 1.4.3.2.2 | BEKISTING | 2d | 2016-12-02 | 2016-12-05 | 44SS | 15d |
| 49 | 1.4.3.2.3 | PENGECORAN | 1d | 2016-12-06 | 2016-12-06 | 45SS | 14d |
| 50 | 1.4.4 | **BALOK** | 6d | 2016-11-24 | 2016-12-01 |  | 0d |
| 51 | 1.4.4.1 | PEMBESIAN | 3d | 2016-11-28 | 2016-11-30 | 52 | 0d |
| 52 | 1.4.4.2 | BEKISTING | 2d | 2016-11-24 | 2016-11-25 | 36 | 0d |
| 53 | 1.4.4.3 | PENGECORAN | 1d | 2016-12-01 | 2016-12-01 | 51 | 0d |

| ID | WBS | Task | Type | Duration | Start | Finish | Predecessors | Total slack | Free slack |
| --- | --- | --- | --- | --- | --- | --- | --- | --- | --- |
| 54 | 1.4.5 | **RING BALOK** |  | 6d | 2016-12-07 | 2016-12-14 |  | 0d |  |
| 55 | 1.4.5.1 | BEKISTING |  | 3d | 2016-12-07 | 2016-12-09 | 45 | 0d |  |
| 56 | 1.4.5.2 | PEMBESIAN |  | 2d | 2016-12-12 | 2016-12-13 | 55 | 0d |  |
| 57 | 1.4.5.3 | PENGECORAN |  | 1d | 2016-12-14 | 2016-12-14 | 56 | 0d |  |
| 58 | 1.4.6 | **TANGGA** |  | 6d | 2016-12-07 | 2016-12-14 |  | 8d |  |
| 59 | 1.4.6.1 | PEMBESIAN |  | 3d | 2016-12-07 | 2016-12-09 | 55SS | 11d |  |
| 60 | 1.4.6.2 | BEKISTING |  | 2d | 2016-12-12 | 2016-12-13 | 56SS | 8d | 0d |
| 61 | 1.4.6.3 | PENGECORAN |  | 1d | 2016-12-14 | 2016-12-14 | 60 | 8d |  |
| 62 | 1.4.7 | **PLAT LANTAI** |  | 6d | 2016-11-24 | 2016-12-01 |  | 17d |  |
| 63 | 1.4.7.1 | BEKISTING |  | 3d | 2016-11-24 | 2016-11-28 | 52SS | 20d |  |
| 64 | 1.4.7.2 | PEMBESIAN |  | 2d | 2016-11-28 | 2016-11-29 | 51SS | 19d |  |
| 65 | 1.4.7.3 | PENGECORAN |  | 1d | 2016-12-01 | 2016-12-01 | 53SS | 17d |  |
| 66 | 1.5 | **PEKERJAAN ATAP** |  | 8d | 2016-12-15 | 2016-12-26 |  | 0d |  |
| 67 | 1.5.1 | **RANGKA ATAP** |  | 4d | 2016-12-15 | 2016-12-20 |  | 0d |  |
| 68 | 1.5.1.1 | PEMASANGAN KUDA-KUDA |  | 2d | 2016-12-15 | 2016-12-16 | 57 | 0d |  |
| 69 | 1.5.1.2 | PEMASANGAN GORDING |  | 2d | 2016-12-19 | 2016-12-20 | 68 | 0d |  |
| 70 | 1.5.2 | **PENUTUP ATAP** |  | 4d | 2016-12-21 | 2016-12-26 |  | 0d |  |
| 71 | 1.5.2.1 | PEMASANGAN ATAP GENTENG |  | 2d | 2016-12-21 | 2016-12-22 | 69 | 0d |  |
| 72 | 1.5.2.2 | PEMASANGAN BUBUNGAN |  | 1d | 2016-12-26 | 2016-12-26 | 73 | 0d |  |
| 73 | 1.5.2.3 | PEMASANGAN LISTPLANK |  | 1d | 2016-12-23 | 2016-12-23 | 71 | 0d |  |
| 74 | 1.6 | **PEKERJAAN M.E.P** |  | 0d | 2016-10-02 | 2016-10-02 |  | 60d |  |
| 75 | 1.6.1 | **PEKERJAAN ELEKTRIKAL** |  | 0d | 2016-10-02 | 2016-10-02 |  | 60d |  |
| 76 | 1.6.1.1 | PEMASANGAN SAKLAR | milestone | 0d | 2016-10-02 | 2016-10-02 |  | 60d |  |
| 77 | 1.6.1.2 | PEMASANGAN SEKRING | milestone | 0d | 2016-10-02 | 2016-10-02 |  | 60d |  |
| 78 | 1.6.1.3 | PEMASANGAN STOP KONTAK | milestone | 0d | 2016-10-02 | 2016-10-02 |  | 60d |  |
| 79 | 1.6.1.4 | PEMASANGAN PANEL LISTRIK | milestone | 0d | 2016-10-02 | 2016-10-02 |  | 60d |  |
| 80 | 1.6.1.5 | PEMASANGAN TITIK LAMPU | milestone | 0d | 2016-10-02 | 2016-10-02 |  | 60d |  |
